# GROUP 7_NURRAWAIDAH BINTI KAMALUDIN_TEST

Schedule from MS Project, 2005-11-22 to 2005-12-26, costs in $.
user

## Calendars

- Standard: Mon-Fri 08:00-12:00, 13:00-17:00; Sat-Sun off.

## Resources

| Resource | Rate |
| --- | --- |
| Sanitary basin | 245 |
| Sanitary close couple wash down | 490 |
| Sanitary floor trap | 10.5 |
| Sanitary hand bidet set complete | 35 |
| Sanitary miror | 245 |
| Sanitary Semi recessed soup dish | 35 |
| Sanitary shower | 126 |
| Sanitary sink | 245 |
| Sanitary soup holder | 35 |
| Sanitary tap and hand bidet | 35 |
| Sanitary toilet roll holder | 35 |
| Sanitary towel rail | 35 |
| Sanitary water closet | 560 |
| Sanitary water trough | 105 |
| Skill Worker | 12.5 |
| Acrylonitrile Butadiene Styrene pipe | 7000 |
| Fibreglass Reinforce Polyester Water tank 660 gallon and accessories | 1578 |
| General Labour | 6.25 |
| Sanitary appliances | 125 |
| Testing plumbing | 62.5 |
| Plumber | 10 |
| Cabinet Type BT 1 | 175 |
| Cabinet Type B 13 | 616 |
| Cabinet Type B 15 | 315 |
| Cabinet Type G 8 | 350 |
| Cabinet Type KK 2 | 560 |
| Cabinet Type KK 6 | 175 |
| Cabinet Type RM 1 | 357 |
| Cabinet Type RT 1 | 1050 |
| cabinet Type S 18 | 840 |
| Carpenter and Joiner | 10 |
| Furnishing Concrete Base Grade 30 | 154 |
| Furnishing Concrete Base REF A6 | 10.5 |
| Furnishing Concrete Based Class F1 | 4.38 |
| Wardrobe Type BT 5 | 574 |
| Wardrobe Type KT 6 | 357 |
| Pavior/Plasterer | 8 |
| plastering 16mm thick 1:6 | 9.9 |
| Water proofing | 3 |
| Painter | 8.75 |
| Paint under coat | 4 |
| Paint finishing coat | 7.2 |
| Ceiling linning | 70 |
| Ceiling installment | 42 |
| Half brickwall 1:3 | 39.7 |
| Tile Fixer | 10.63 |
| 300 x 300 x 8.5mm non slipt heavy duty homogeneius tiles | 86.1 |
| Skirting 100mm high | 38 |

## Schedule

| ID | WBS | Task | Duration | Start | Finish | Predecessors | Total slack | Free slack | Resources | Work | Cost |
| --- | --- | --- | --- | --- | --- | --- | --- | --- | --- | --- | --- |
| 1 | 1 | **INTERNAL WORK** | 14d | 2005-11-22 | 2005-12-09 |  | 11d |  |  | 984h | 51,136.04 |
| 2 | 1.1 | **Sanitary Installation** | 14d | 2005-11-22 | 2005-12-09 |  | 11d |  |  | 448h | 14,091 |
| 3 | 1.1.1 | Sanitary Fitting | 14d | 2005-11-22 | 2005-12-09 |  | 11d | 0d | Sanitary basin [400%]; Sanitary close couple wash down [400%]; Sanitary floor trap [1000%]; Sanitary hand bidet set complete [600%]; Sanitary miror [600%]; Sanitary Semi recessed soup dish [200%]; Sanitary shower [600%]; Sanitary sink [400%]; Sanitary soup holder [400%]; Sanitary tap and hand bidet [200%]; Sanitary toilet roll holder [600%]; Sanitary towel rail [600%]; Sanitary water closet [200%]; Sanitary water trough [200%]; Skill Worker [400%] | 448h | 14,091 |
| 4 | 1.2 | **Plumbing Installation** | 11d | 2005-11-22 | 2005-12-06 |  | 14d |  |  | 312h | 16,598 |
| 5 | 1.2.1 | Cold Water Systems | 2d | 2005-11-22 | 2005-11-23 | 3SS | 14d | 0d | Acrylonitrile Butadiene Styrene pipe; Skill Worker [200%] | 32h | 7,400 |
| 6 | 1.2.2 | Storage Water Tank | 2d | 2005-11-24 | 2005-11-25 | 5 | 14d | 0d | Fibreglass Reinforce Polyester Water tank 660 gallon and accessories; Skill Worker [200%]; General Labour [200%] | 64h | 2,178 |
| 7 | 1.2.3 | Sanitary Pipe Installation | 2d | 2005-11-24 | 2005-11-25 | 6SS | 14d | 0d | Sanitary appliances; Skill Worker [200%] | 48h | 2,400 |
| 8 | 1.2.4 | Testing Pipework | 7d | 2005-11-28 | 2005-12-06 | 5, 6, 7 | 14d |  | Testing plumbing; Plumber [200%] | 168h | 4,620 |
| 9 | 1.3 | **Cabinet Installation** | 9d | 2005-11-22 | 2005-12-02 |  | 16d |  |  | 144h | 17,571.52 |
| 10 | 1.3.1 | Cabinet Fitting | 5d | 2005-11-22 | 2005-11-28 | 3SS | 16d | 0d | Cabinet Type BT 1 [600%]; Cabinet Type B 13 [400%]; Cabinet Type B 15 [400%]; Cabinet Type G 8 [400%]; Cabinet Type KK 2 [200%]; Cabinet Type KK 6 [200%]; Cabinet Type RM 1 [200%]; Cabinet Type RT 1 [400%]; cabinet Type S 18 [400%]; Carpenter and Joiner [200%] | 80h | 16,718 |
| 11 | 1.3.2 | Furnishing | 4d | 2005-11-29 | 2005-12-02 | 10 | 16d |  | Furnishing Concrete Base Grade 30; Furnishing Concrete Base REF A6 [400%]; Furnishing Concrete Based Class F1 [400%]; Carpenter and Joiner [200%] | 64h | 853.52 |
| 12 | 1.4 | **Wardrobe Installation** | 5d | 2005-11-22 | 2005-11-28 |  | 20d |  |  | 80h | 2,875.52 |
| 13 | 1.4.1 | Wardrobe Fitting | 3d | 2005-11-22 | 2005-11-24 | 3SS | 20d | 0d | Wardrobe Type BT 5 [200%]; Wardrobe Type KT 6 [200%]; Carpenter and Joiner [200%] | 48h | 2,342 |
| 14 | 1.4.2 | Furnishing | 2d | 2005-11-25 | 2005-11-28 | 13 | 20d |  | Furnishing Concrete Base Grade 30; Furnishing Concrete Base REF A6 [400%]; Furnishing Concrete Based Class F1 [400%]; Carpenter and Joiner [200%] | 32h | 533.52 |
| 15 | 2 | **EXTERNAL WORK** | 25d | 2005-11-22 | 2005-12-26 |  | 0d |  |  | 5096h | 58,067.4 |
| 16 | 2.1 | **Finishes** | 25d | 2005-11-22 | 2005-12-26 |  | 0d |  |  | 5096h | 58,067.4 |
| 17 | 2.1.1 | **Wall** | 11d | 2005-11-22 | 2005-12-06 |  | 0d |  |  | 4256h | 42,281 |
| 18 | 2.1.1.1 | **ground floor** | 11d | 2005-11-22 | 2005-12-06 |  | 0d |  |  | 2960h | 29,422 |
| 19 | 2.1.1.1.1 | Plastering | 7d | 2005-11-22 | 2005-11-30 |  | 0d |  | Pavior/Plasterer [200%]; plastering 16mm thick 1:6 [5000%] | 2912h | 28,616 |
| 20 | 2.1.1.1.2 | Water Proofing | 1d | 2005-11-30 | 2005-11-30 | 19FF | 0d |  | General Labour; Water proofing [3000%] | 8h | 140 |
| 21 | 2.1.1.1.3 | **painting** | 3d | 2005-12-01 | 2005-12-05 |  | 0d |  |  | 32h | 616 |
| 22 | 2.1.1.1.3.1 | Under Coat | 1d | 2005-12-01 | 2005-12-01 | 20 | 0d |  | Painter [200%]; Paint under coat [3000%] | 16h | 260 |
| 23 | 2.1.1.1.3.2 | Finishing Coat | 2d | 2005-12-02 | 2005-12-05 | 22 | 0d |  | Painter; Paint finishing coat [3000%] | 16h | 356 |
| 24 | 2.1.1.1.4 | Cleaning | 1d | 2005-12-06 | 2005-12-06 | 23 | 14d |  | General Labour | 8h | 50 |

| ID | WBS | Task | Duration | Start | Finish | Predecessors | Total slack | Free slack | Resources | Work | Cost |
| --- | --- | --- | --- | --- | --- | --- | --- | --- | --- | --- | --- |
| 25 | 2.1.1.2 | **first floor** | 11d | 2005-11-22 | 2005-12-06 |  | 12d |  |  | 1296h | 12,859 |
| 26 | 2.1.1.2.1 | Plastering | 7d | 2005-11-22 | 2005-11-30 | 19SS | 12d | 0d | Pavior/Plasterer [200%]; plastering 16mm thick 1:6 [2000%] | 1232h | 11,984 |
| 27 | 2.1.1.2.2 | Water Proofing | 1d | 2005-11-30 | 2005-11-30 | 26FF | 12d | 0d | General Labour; Water proofing [2500%] | 8h | 125 |
| 28 | 2.1.1.2.3 | **painting** | 3d | 2005-12-01 | 2005-12-05 |  | 12d |  |  | 48h | 700 |
| 29 | 2.1.1.2.3.1 | Under Coat | 1d | 2005-12-01 | 2005-12-01 | 27 | 12d | 0d | Painter [200%]; Paint under coat [2500%] | 16h | 240 |
| 30 | 2.1.1.2.3.2 | Finishing Coat | 2d | 2005-12-02 | 2005-12-05 | 29 | 12d | 0d | Painter [200%]; Paint finishing coat [2500%] | 32h | 460 |
| 31 | 2.1.1.2.4 | Cleaning | 1d | 2005-12-06 | 2005-12-06 | 30 | 14d |  | General Labour | 8h | 50 |
| 32 | 2.1.2 | **Ceiling** | 6d | 2005-12-06 | 2005-12-13 |  | 0d |  |  | 720h | 10,390 |
| 33 | 2.1.2.1 | **ground floor** | 6d | 2005-12-06 | 2005-12-13 |  | 0d |  |  | 672h | 6,702 |
| 34 | 2.1.2.1.1 | Plastering | 3d | 2005-12-06 | 2005-12-08 | 23 | 0d |  | Pavior/Plasterer [200%]; plastering 16mm thick 1:6 [2500%] | 648h | 6,324 |
| 35 | 2.1.2.1.2 | **painting** | 3d | 2005-12-09 | 2005-12-13 |  | 0d |  |  | 24h | 378 |
| 36 | 2.1.2.1.2.1 | Under Coat | 1d | 2005-12-09 | 2005-12-09 | 34 | 0d |  | Painter; Paint under coat [1500%] | 8h | 130 |
| 37 | 2.1.2.1.2.2 | Finishing Coat | 2d | 2005-12-12 | 2005-12-13 | 36 | 0d |  | Painter; Paint finishing coat [1500%] | 16h | 248 |
| 38 | 2.1.2.2 | **first floor** | 3d | 2005-12-06 | 2005-12-08 |  | 12d |  |  | 48h | 3,688 |
| 39 | 2.1.2.2.1 | Lining | 2d | 2005-12-06 | 2005-12-07 | 30 | 12d | 0d | Ceiling linning [3400%]; General Labour [200%] | 32h | 2,580 |
| 40 | 2.1.2.2.2 | Ceiling Board | 1d | 2005-12-08 | 2005-12-08 | 39 | 12d |  | Ceiling installment [2400%]; General Labour [200%] | 16h | 1,108 |
| 41 | 2.1.3 | **Floor** | 9d | 2005-12-14 | 2005-12-26 |  | 0d |  |  | 120h | 5,396.4 |
| 42 | 2.1.3.1 | **ground Floor** | 9d | 2005-12-14 | 2005-12-26 |  | 0d |  |  | 120h | 5,396.4 |
| 43 | 2.1.3.1.1 | Rendering | 1d | 2005-12-14 | 2005-12-14 | 37 | 0d |  | General Labour; Half brickwall 1:3 [3000%] | 8h | 1,241 |
| 44 | 2.1.3.1.2 | Water Proofing | 1d | 2005-12-14 | 2005-12-14 | 43FF | 0d |  | Water proofing [500%]; General Labour | 8h | 65 |
| 45 | 2.1.3.1.3 | Tiling | 5d | 2005-12-15 | 2005-12-21 | 44 | 0d |  | Tile Fixer [200%]; 300 x 300 x 8.5mm non slipt heavy duty homogeneius tiles [2000%] | 80h | 2,572.4 |
| 46 | 2.1.3.1.4 | Skirting | 2d | 2005-12-22 | 2005-12-23 | 45 | 0d |  | General Labour; Skirting 100mm high [3600%] | 16h | 1,468 |
| 47 | 2.1.3.1.5 | Cleaning | 1d | 2005-12-26 | 2005-12-26 | 46 | 0d |  | General Labour | 8h | 50 |
